# schedule

Schedule from MS Project, 2005-04-25 to 2005-07-15, costs in $, A marks actual dates.
shade

## Calendars

- Standard: Mon-Sun 08:00-12:00, 13:00-17:00.

## Resources

| Resource | Rate |
| --- | --- |
| Jason Kealey | 25 |
| Etienne Tremblay | 25 |
| Jean-Philippe Daigle | 25 |
| Jordan McManus | 25 |
| Olivier Clift-Noel | 25 |
| Jean-François Roy |  |
| Daniel Amyot |  |
| Ali Echihabi |  |

## Schedule

| ID | WBS | Task | Duration | Start | Finish | Predecessors | Complete | Total slack | Free slack | Constraint | Resources | Work | Actual work | Cost | Actual cost |
| --- | --- | --- | --- | --- | --- | --- | --- | --- | --- | --- | --- | --- | --- | --- | --- |
| 1 | 1 | **Implement current tests** | 15d | 2005-04-25 A | 2005-05-09 A |  | 100% |  |  |  | Jason Kealey | 240h | 240h | 6,000 | 6,000 |
| 2 | 1.1 | Refine test plan | 1w | 2005-04-25 A | 2005-04-29 A |  | 100% |  |  | start no earlier than 2005-04-25 | Jason Kealey | 40h | 40h | 1,000 | 1,000 |
| 3 | 1.2 | Implement pre/post conditions for commands | 1w | 2005-04-30 A | 2005-05-04 A | 2 | 100% |  |  | start no earlier than 2005-04-30 | Jason Kealey | 40h | 40h | 1,000 | 1,000 |
| 4 | 1.3 | Implement requirement tests | 1w | 2005-05-05 A | 2005-05-09 A | 3 | 100% |  |  | start no earlier than 2005-05-05 | Jason Kealey | 40h | 40h | 1,000 | 1,000 |
| 5 | 2 | Multiple UCMs per File | 1w | 2005-04-30 A | 2005-05-04 A |  | 100% |  |  | start no earlier than 2005-04-30 | Jason Kealey | 40h | 40h | 1,000 | 1,000 |
| 6 | 3 | Review architecture | 1w | 2005-05-10 A | 2005-05-14 A | 24, 25 | 100% |  |  | start no earlier than 2005-05-10 | Jason Kealey | 40h | 40h | 1,000 | 1,000 |
| 7 | 4 | ReqCompCompBind | 1w | 2005-05-15 A | 2005-05-19 A |  | 100% |  |  | start no earlier than 2005-05-15 | Jason Kealey | 40h | 40h | 1,000 | 1,000 |
| 8 | 5 | ReqCompCompUnbind | 1w | 2005-05-15 A | 2005-05-19 A |  | 100% |  |  | start no earlier than 2005-05-15 | Jason Kealey | 40h | 40h | 1,000 | 1,000 |
| 9 | 6 | ReqCompPathBind | 1w | 2005-05-20 A | 2005-05-24 A | 7, 8 | 100% |  |  | start no earlier than 2005-05-20 | Jason Kealey | 40h | 40h | 1,000 | 1,000 |
| 10 | 7 | ReqCompPathUnbind | 1w | 2005-05-20 A | 2005-05-24 A | 7, 8 | 100% |  |  | start no earlier than 2005-05-20 | Jason Kealey | 40h | 40h | 1,000 | 1,000 |
| 11 | 8 | **Milestone Five** | 10d | 2005-05-25 A | 2005-06-03 A |  | 100% |  |  |  | Jason Kealey | 160h | 160h | 4,000 | 4,000 |
| 12 | 8.1 | Quality assurance | 1w | 2005-05-25 A | 2005-05-29 A |  | 100% |  |  | start no earlier than 2005-05-25 | Jason Kealey | 40h | 40h | 1,000 | 1,000 |
| 13 | 8.2 | Report preperation | 1w | 2005-05-30 A | 2005-06-03 A | 12 | 100% |  |  | start no earlier than 2005-05-30 | Jason Kealey | 40h | 40h | 1,000 | 1,000 |
| 14 | 9 | ReqElemAndFork | 1w | 2005-04-25 A | 2005-04-29 A |  | 100% |  |  | start no earlier than 2005-04-25 | Jean-Philippe Daigle | 40h | 40h | 1,000 | 1,000 |
| 15 | 10 | ReqElemAndJoin | 1w | 2005-04-30 A | 2005-05-04 A | 14 | 100% |  |  | start no earlier than 2005-04-30 | Jean-Philippe Daigle | 40h | 40h | 1,000 | 1,000 |
| 16 | 11 | ReqElemOrFork | 1d | 2005-05-05 A | 2005-05-05 A | 15 | 100% |  |  | start no earlier than 2005-05-05 | Jean-Philippe Daigle | 8h | 8h | 200 | 200 |
| 17 | 12 | ReqElemOrJoin | 1d | 2005-05-05 A | 2005-05-05 A | 15 | 100% |  |  | start no earlier than 2005-05-05 | Jean-Philippe Daigle | 8h | 8h | 200 | 200 |
| 18 | 13 | ReqElemWait | 1d | 2005-05-06 | 2005-05-06 | 16, 17 |  | 63d | 0d | start no earlier than 2005-05-06 | Jean-Philippe Daigle | 8h |  | 200 |  |
| 19 | 14 | ReqElemTimer | 1w | 2005-05-07 | 2005-05-11 | 18 |  | 63d |  | start no earlier than 2005-05-07 | Jean-Philippe Daigle | 40h |  | 1,000 |  |
| 20 | 15 | ReqConnections | 1w | 2005-05-12 | 2005-05-16 |  |  | 58d |  | start no earlier than 2005-05-12 | Jean-Philippe Daigle | 40h |  | 1,000 |  |
| 21 | 16 | UI QA & Cleanup | 3w | 2005-05-17 | 2005-05-31 |  |  | 43d |  | start no earlier than 2005-05-17 | Jean-Philippe Daigle | 120h |  | 3,000 |  |
| 22 | 17 | **Milestone Four** | 15d | 2005-04-25 A | 2005-05-09 A |  | 100% |  |  |  | Etienne Tremblay | 320h | 320h | 8,000 | 8,000 |
| 23 | 17.1 | In depth architecture investigation | 1w | 2005-04-25 A | 2005-04-29 A |  | 100% |  |  | start no earlier than 2005-04-25 | Etienne Tremblay | 40h | 40h | 1,000 | 1,000 |
| 24 | 17.2 | Package diagram | 2w | 2005-04-30 A | 2005-05-09 A | 23 | 100% |  |  | start no earlier than 2005-04-30 | Etienne Tremblay | 80h | 80h | 2,000 | 2,000 |
| 25 | 17.3 | Interaction scenarios | 2w | 2005-04-30 A | 2005-05-09 A | 23 | 100% |  |  | start no earlier than 2005-04-30 | Etienne Tremblay | 80h | 80h | 2,000 | 2,000 |
| 26 | 18 | ReqElemDynamicStub | 2d | 2005-05-06 A | 2005-05-07 A | 16, 17 | 100% |  |  | start no earlier than 2005-05-06 | Etienne Tremblay | 16h | 16h | 400 | 400 |
| 27 | 19 | ReqElemStaticStub | 1d | 2005-05-08 A | 2005-05-08 A | 26 | 100% |  |  | start no earlier than 2005-05-08 | Etienne Tremblay | 8h | 8h | 200 | 200 |

| ID | WBS | Task | Duration | Start | Finish | Predecessors | Complete | Remaining | Total slack | Free slack | Constraint | Resources | Work | Actual work | Cost | Actual cost |
| --- | --- | --- | --- | --- | --- | --- | --- | --- | --- | --- | --- | --- | --- | --- | --- | --- |
| 28 | 20 | **ReqElemStubActions** | 10d | 2005-05-09 A | 2005-05-18 | 27, 26, 5 | 90% | 1d | 57d |  |  | Etienne Tremblay | 160h | 144h | 4,000 | 3,600 |
| 29 | 20.1 | Binding Property Page | 1w | 2005-05-09 A | 2005-05-13 A |  | 100% |  |  |  | start no earlier than 2005-05-09 | Etienne Tremblay | 40h | 40h | 1,000 | 1,000 |
| 30 | 20.2 | Plugin support | 1w | 2005-05-14 A | 2005-05-18 | 29 | 80% | 0.2w | 57d |  | start no earlier than 2005-05-14 | Etienne Tremblay | 40h | 32h | 1,000 | 800 |
| 31 | 21 | **ReqElemDelete** | 15d | 2005-05-19 A | 2005-06-02 |  | 93% | 1d | 42d |  |  | Etienne Tremblay | 240h | 224h | 6,000 | 5,600 |
| 32 | 21.1 | Downgrade PathNode to EmptyNode | 1d | 2005-05-19 | 2005-05-19 |  |  |  | 41d | 0d | start no earlier than 2005-05-19 | Etienne Tremblay | 8h |  | 200 |  |
| 33 | 21.2 | Delete simple PathNodes | 2d | 2005-05-20 A | 2005-05-21 A | 32 | 100% |  |  |  | start no earlier than 2005-05-20 | Etienne Tremblay | 16h | 16h | 400 | 400 |
| 34 | 21.3 | Delete ComponentRefs | 2d | 2005-05-22 A | 2005-05-23 A | 33 | 100% |  |  |  | start no earlier than 2005-05-22 | Etienne Tremblay | 16h | 16h | 400 | 400 |
| 35 | 21.4 | Delete Full Path | 1w | 2005-05-24 A | 2005-05-28 A | 34 | 100% |  |  |  | start no earlier than 2005-05-24 | Etienne Tremblay | 40h | 40h | 1,000 | 1,000 |
| 36 | 21.5 | Delete Partial Path | 1w | 2005-05-29 A | 2005-06-02 A | 35 | 100% |  |  |  | start no earlier than 2005-05-29 | Etienne Tremblay | 40h | 40h | 1,000 | 1,000 |
| 37 | 22 | ReqLabels | 1w | 2005-04-25 A | 2005-04-29 A |  | 100% |  |  |  | start no earlier than 2005-04-25 | Jordan McManus | 40h | 40h | 1,000 | 1,000 |
| 38 | 23 | ReqSaveBackup | 2w | 2005-04-30 | 2005-05-09 |  |  |  | 65d |  | start no earlier than 2005-04-30 | Jordan McManus | 80h |  | 2,000 |  |
| 39 | 24 | ReqElemEndPoint | 3d | 2005-05-11 A | 2005-05-13 A | 37 | 100% |  |  |  | start no earlier than 2005-05-11 | Jordan McManus | 24h | 24h | 600 | 600 |
| 40 | 25 | ReqElemStartPoint | 3d | 2005-05-11 A | 2005-05-13 A | 37 | 100% |  |  |  | start no earlier than 2005-05-11 | Jordan McManus | 24h | 24h | 600 | 600 |
| 41 | 26 | ReqElemStartPointAttributes | 1d | 2005-05-14 A | 2005-05-14 A | 40 | 100% |  |  |  | start no earlier than 2005-05-14 | Jordan McManus | 8h | 8h | 200 | 200 |
| 42 | 27 | ReqElemDirectionArrow | 1w | 2005-05-15 A | 2005-05-19 A |  | 100% |  |  |  | start no earlier than 2005-05-15 | Jordan McManus | 40h | 40h | 1,000 | 1,000 |
| 43 | 28 | ReqExportBitmap | 1w | 2005-05-20 A | 2005-05-24 |  | 80% | 0.2w | 51d |  | start no earlier than 2005-05-20 | Jordan McManus | 40h | 32h | 1,000 | 800 |
| 44 | 29 | Code QA & Cleanup | 2w | 2005-05-26 | 2005-06-04 |  |  |  | 39d |  | start no earlier than 2005-05-26 | Jordan McManus | 80h |  | 2,000 |  |
| 45 | 30 | ReqHelpAbout | 2d | 2005-04-25 A | 2005-04-26 A |  | 100% |  |  |  | start no earlier than 2005-04-25 | Olivier Clift-Noel | 16h | 16h | 400 | 400 |
| 46 | 31 | ReqBrowseHistory | 3d | 2005-04-25 A | 2005-04-27 A |  | 100% |  |  |  | start no earlier than 2005-04-25 | Olivier Clift-Noel | 24h | 24h | 600 | 600 |
| 47 | 32 | **ReqBrowseModel** | 20d | 2005-04-28 A | 2005-05-17 | 46 | 35% | 13d | 17d |  |  | Olivier Clift-Noel | 320h | 112h | 8,000 | 2,800 |
| 48 | 32.1 | Outline View | 1w | 2005-04-28 A | 2005-05-02 A |  | 100% |  |  |  | start no earlier than 2005-04-28 | Olivier Clift-Noel | 40h | 40h | 1,000 | 1,000 |
| 49 | 32.2 | Responsibilities View | 1w | 2005-05-03 A | 2005-05-07 | 48 | 40% | 0.6w | 43d | 0d | start no earlier than 2005-05-03 | Olivier Clift-Noel | 40h | 16h | 1,000 | 400 |
| 50 | 32.3 | Description Panel | 1w | 2005-05-08 | 2005-05-12 | 49 |  |  | 42d | 0d | start no earlier than 2005-05-08 | Olivier Clift-Noel | 40h |  | 1,000 |  |
| 51 | 32.4 | Upgrade other views with actions | 1w | 2005-05-13 | 2005-05-17 | 50 |  |  | 42d | 17d | start no earlier than 2005-05-13 | Olivier Clift-Noel | 40h |  | 1,000 |  |

| ID | WBS | Task | Type | Duration | Start | Finish | Predecessors | Complete | Remaining | Total slack | Free slack | Constraint | Resources | Work | Actual work | Cost | Actual cost |
| --- | --- | --- | --- | --- | --- | --- | --- | --- | --- | --- | --- | --- | --- | --- | --- | --- | --- |
| 52 | 33 | **ReqHelpOnLine** |  | 15d | 2005-05-18 A | 2005-06-01 |  | 27% | 11d | 43d |  |  | Olivier Clift-Noel | 240h | 64h | 6,000 | 1,600 |
| 53 | 33.1 | Define outline |  | 1w | 2005-05-18 A | 2005-05-22 |  | 80% | 0.2w | 43d | 0d | start no earlier than 2005-05-18 | Olivier Clift-Noel | 40h | 32h | 1,000 | 800 |
| 54 | 33.2 | Gather content |  | 1w | 2005-05-23 | 2005-05-27 | 53 |  |  | 42d | 0d | start no earlier than 2005-05-23 | Olivier Clift-Noel | 40h |  | 1,000 |  |
| 55 | 33.3 | Tie up loose ends |  | 1w | 2005-05-28 | 2005-06-01 | 54 |  |  | 42d |  | start no earlier than 2005-05-28 | Olivier Clift-Noel | 40h |  | 1,000 |  |
| 56 | 34 | **ReqDocumentation** |  | 15d | 2005-06-04 A | 2005-06-18 | 51 | 13% | 13d | 25d |  |  | Olivier Clift-Noel | 240h | 32h | 6,000 | 800 |
| 57 | 34.1 | Define outline |  | 1w | 2005-06-04 A | 2005-06-08 |  | 40% | 0.6w | 25d | 0d | start no earlier than 2005-06-04 | Olivier Clift-Noel | 40h | 16h | 1,000 | 400 |
| 58 | 34.2 | Gather content |  | 1w | 2005-06-09 | 2005-06-13 | 57 |  |  | 25d | 0d | start no earlier than 2005-06-09 | Olivier Clift-Noel | 40h |  | 1,000 |  |
| 59 | 34.3 | Tie up loose ends |  | 1w | 2005-06-14 | 2005-06-18 | 58 |  |  | 25d |  | start no earlier than 2005-06-14 | Olivier Clift-Noel | 40h |  | 1,000 |  |
| 60 | 35 | Refine test suite |  | 5w | 2005-05-07 | 2005-05-31 |  |  |  | 43d |  | start no earlier than 2005-05-07 | Olivier Clift-Noel | 200h |  | 5,000 |  |
| 61 | 36 | I know we aren't working at 100% buffer |  | 1mo | 2005-06-04 | 2005-06-23 |  |  |  | 1d | 0d | start no earlier than 2005-06-04 | Jason Kealey; Etienne Tremblay; Jean-Philippe Daigle; Olivier Clift-Noel; Jordan McManus | 800h |  | 20,000 |  |
| 62 | 37 | Quality Assurance and project wrap up |  | 1mo | 2005-06-24 | 2005-07-13 | 61 |  |  | 1d |  | start no earlier than 2005-06-24 | Jason Kealey; Etienne Tremblay; Jean-Philippe Daigle; Olivier Clift-Noel; Jordan McManus | 800h |  | 20,000 |  |
| 63 | 38 | Weekly walkthroughs |  | 81d? | 2005-04-25 A | 2005-07-14 |  | 47% | 43d? | 0d |  |  | Jason Kealey; Etienne Tremblay; Jean-Philippe Daigle; Olivier Clift-Noel; Jordan McManus; Daniel Amyot; Jean-François Roy | 4536h | 2128h | 81,000 | 38,000 |
| 64 | 39 | Bi-weekly review |  | 81d? | 2005-04-25 A | 2005-07-14 |  | 47% | 43d? | 0d |  |  | Daniel Amyot | 648h | 304h |  |  |
| 65 | 40 | Usability Testing, Deployment Testing |  | 10d? | 2005-06-04 | 2005-06-13 |  |  |  | 31d |  | start no earlier than 2005-06-04 | Jean-François Roy; Ali Echihabi; Daniel Amyot | 240h |  |  |  |
| 66 | 41 | Milestone Four | milestone | 0d | 2005-05-13 | 2005-05-13 |  |  |  | 63d |  | start no earlier than 2005-05-13 |  |  |  |  |  |
| 67 | 42 | Milestone Five | milestone | 0d | 2005-06-17 | 2005-06-17 |  |  |  | 28d |  | start no earlier than 2005-06-17 |  |  |  |  |  |
| 68 | 43 | Milestone Six | milestone | 0d | 2005-07-15 | 2005-07-15 |  |  |  | 0d |  | start no earlier than 2005-07-15 |  |  |  |  |  |
